# ISO9001-14001 outline programme (rev03)

Schedule from MS Project, 2017-05-29 to 2020-01-14, status date 2018-03-27.
South Gloucestershire Council

## Calendars

- Standard: Mon-Fri 08:00-12:00, 13:00-17:00; Sat-Sun off. Exceptions (off unless hours are given): 2017-12-18 to 2017-12-22 (Christmas weeks), 2017-12-25 to 2018-01-01 (Christmas weeks).

## Resources

| Resource |
| --- |
| PRM |
| Proj Board |
| Proj Team |
| Metis |
| Coordinator |
| JM |
| NDC |
| MK |
| Audit team |
| Certification body |

## Schedule

| ID | WBS | Task | Type | Duration | Start | Finish | Predecessors | Total slack | Free slack | Constraint |
| --- | --- | --- | --- | --- | --- | --- | --- | --- | --- | --- |
| 1 | 1 | **Bid** |  | 92d | 2017-06-01 | 2017-10-09 |  |  |  |  |
| 2 | 1.1 | Set up Team |  | 1w | 2017-05-29 | 2017-06-02 |  | 639d |  | start no earlier than 2017-05-29 |
| 3 | 1.2 | Initial Project Team meeting | milestone | 0d | 2017-06-05 | 2017-06-05 |  | 639d |  | start no earlier than 2017-06-05 |
| 4 | 1.3 | Engage consultant for economic appraisal | milestone | 0d | 2017-06-12 | 2017-06-12 |  | 634d |  | start no earlier than 2017-06-12 |
| 5 | 1.4 | Prepare bid |  | 4w | 2017-06-19 | 2017-07-14 |  | 609d |  | start no earlier than 2017-06-19 |
| 6 | 1.5 | Submit bid | milestone | 0d | 2017-06-30 | 2017-06-30 |  | 266d | 155d | start no earlier than 2017-06-30 |
| 7 | 1.6 | Award | milestone | 0d | 2017-10-02 | 2017-10-02 |  | 554d |  | start no earlier than 2017-10-02 |
| 9 | 2 | **Utilities** |  | 320d | 2018-02-19 | 2019-05-13 |  |  |  |  |
| 10 | 2.1 | Searches |  | 16w | 2018-02-19 | 2018-06-08 | 6 | 240d |  |  |
| 11 | 2.2 | Identify obvious diversion requirements |  | 20w | 2018-02-19 | 2018-07-06 |  | 220d |  |  |
| 12 | 2.3 | Programme diversions (provisional) |  | 65w | 2018-02-19 | 2019-05-17 |  | -5d | 0d |  |
| 14 | 3 | **Upper Maudlin St - Lower Maudlin/ Upper Maudlin/ Marlborough Street** |  | 175d | 2018-04-02 | 2018-12-03 |  |  |  |  |
| 15 | 3.1 | Investigation |  | 4w | 2018-04-02 | 2018-04-27 | 6FS-1d | 155d |  |  |
| 16 | 3.2 | Notices |  | 3w | 2018-04-02 | 2018-04-20 |  | 160d |  |  |
| 17 | 3.3 | Design | manual | 10w | 2018-04-23 | 2018-07-02 |  |  |  |  |
| 18 | 3.4 | Construction |  | 22w | 2018-07-02 | 2018-11-30 |  | 292d |  | start no earlier than 2018-07-02 |
| 19 | 4 | **Upper Maudlin St - BRI Entrance/ Upper Maudlin St** |  | 175d | 2018-04-16 | 2018-12-17 |  |  |  |  |
| 20 | 4.1 | Investigation |  | 4w | 2018-04-16 | 2018-05-11 |  | 80d |  |  |
| 21 | 4.2 | Notices |  | 3w | 2018-04-16 | 2018-05-04 |  | 160d |  |  |
| 22 | 4.3 | Design |  | 10w | 2018-05-07 | 2018-07-13 |  | 392d |  | start no earlier than 2018-05-07 |
| 23 | 4.4 | Construction |  | 22w | 2018-07-16 | 2018-12-14 |  | 282d |  | start no earlier than 2018-07-16 |
| 24 | 5 | **Upper Maudlin St - Colston St/ St Michael's Hill/ Upper Maudlin St** |  | 175d | 2018-04-23 | 2018-12-24 |  |  |  |  |
| 25 | 5.1 | Investigation |  | 4w | 2018-04-23 | 2018-05-18 |  | 15d | 0d | start no earlier than 2018-04-23 |
| 26 | 5.2 | Notices |  | 3w | 2018-04-23 | 2018-05-11 |  | 160d |  |  |
| 27 | 5.3 | Design |  | 8.8w | 2018-05-15 | 2018-07-13 |  | 392d |  | start no earlier than 2018-05-15 |
| 28 | 5.4 | Construction |  | 23w | 2018-07-16 | 2018-12-21 |  | 277d |  | start no earlier than 2018-07-16 |

| ID | WBS | Task | Duration | Start | Finish | Predecessors | Total slack | Constraint |
| --- | --- | --- | --- | --- | --- | --- | --- | --- |
| 29 | 6 | **Upper Maudlin St - Park Row (B4051) j/w Lower Park Row** | 190d | 2018-04-30 | 2019-01-21 |  |  |  |
| 30 | 6.1 | Investigation | 4w | 2018-04-30 | 2018-05-25 |  | 607d | start no earlier than 2018-04-30 |
| 31 | 6.2 | Notices | 3w | 2018-04-30 | 2018-05-18 |  | 175d |  |
| 32 | 6.3 | Design | 9.4w | 2018-05-17 | 2018-07-20 |  | 387d | start no earlier than 2018-05-17 |
| 33 | 6.4 | Construction | 27w | 2018-07-23 | 2019-01-25 |  | 252d | start no earlier than 2018-07-23 |
| 34 | 7 | **A38 Ashley Down Road jnc to Filton Avenue** | 100d | 2018-05-07 | 2018-09-21 |  |  |  |
| 35 | 7.1 | Investigation | 4w | 2018-05-07 | 2018-06-01 |  | 602d | start no earlier than 2018-05-07 |
| 36 | 7.2 | Notices | 3w | 2018-05-07 | 2018-05-25 |  | 427d | start no earlier than 2018-05-07 |
| 37 | 7.3 | Design | 5w | 2018-06-18 | 2018-07-20 |  | 387d | start no earlier than 2018-06-18 |
| 38 | 7.4 | Construction | 8w | 2018-07-30 | 2018-09-21 |  | 522d | start no earlier than 2018-07-30 |
| 39 | 8 | **A431 Jnc with Kingsway** | 210d | 2018-05-07 | 2019-02-25 |  |  |  |
| 40 | 8.1 | Investigation | 4w | 2018-05-07 | 2018-06-01 |  | 602d | start no earlier than 2018-05-07 |
| 41 | 8.2 | Notices | 3w | 2018-05-07 | 2018-05-25 |  | 427d | start no earlier than 2018-05-07 |
| 42 | 8.3 | Design | 8w | 2018-06-04 | 2018-07-27 | 40 | 150d |  |
| 43 | 8.4 | Construction | 30w | 2018-07-30 | 2019-02-22 |  | 232d | start no earlier than 2018-07-30 |
| 44 | 9 | **A431 Jnc with Whittucks Road** | 244d | 2018-05-01 | 2019-04-08 |  |  |  |
| 45 | 9.1 | Investigation | 4w | 2018-05-01 | 2018-05-28 |  | 426d | start no earlier than 2018-05-01 |
| 46 | 9.2 | Notices | 3w | 2018-05-01 | 2018-05-21 |  | 431d | start no earlier than 2018-05-01 |
| 47 | 9.3 | Design | 14.6w | 2018-05-16 | 2018-08-24 |  | 362d | start no earlier than 2018-05-16 |
| 48 | 9.4 | Construction | 31w | 2018-08-27 | 2019-03-29 |  | 207d | start no earlier than 2018-08-27 |
| 49 | 10 | **A431 Jnc with Aldermoor Way** | 259d | 2018-05-01 | 2019-04-29 |  |  |  |
| 50 | 10.1 | Investigation | 4w | 2018-05-01 | 2018-05-28 |  | 426d | start no earlier than 2018-05-01 |
| 51 | 10.2 | Notices | 3w | 2018-05-01 | 2018-05-21 |  | 431d | start no earlier than 2018-05-01 |
| 52 | 10.3 | Design | 17w | 2018-06-04 | 2018-09-28 |  | 337d | start no earlier than 2018-06-04 |
| 53 | 10.4 | Construction | 30w | 2018-10-01 | 2019-04-26 |  | 187d | start no earlier than 2018-10-01 |

| ID | WBS | Task | Type | Duration | Start | Finish | Total slack | Free slack | Constraint |
| --- | --- | --- | --- | --- | --- | --- | --- | --- | --- |
| 54 | 11 | **A431 Brougham Hayes jnc with A36** |  | 220d | 2018-07-16 | 2019-05-20 |  |  |  |
| 55 | 11.1 | Investigation |  | 4w | 2018-07-16 | 2018-08-10 | 552d |  | start no earlier than 2018-07-16 |
| 56 | 11.2 | Notices |  | 6w | 2018-07-16 | 2018-08-24 | 542d |  | start no earlier than 2018-07-16 |
| 57 | 11.3 | Design |  | 8w | 2018-08-27 | 2018-10-19 | 322d |  | start no earlier than 2018-08-27 |
| 58 | 11.4 | Construction |  | 32w | 2018-10-08 | 2019-05-17 | 172d |  | start no earlier than 2018-10-08 |
| 59 | 12 | **A4017 (Cleeve Hill) - A432 Badminton Rd / Cleeve Rd** |  | 180d | 2019-04-01 | 2019-12-09 |  |  |  |
| 60 | 12.1 | Investigation |  | 4w | 2019-04-01 | 2019-04-26 | 160d |  |  |
| 61 | 12.2 | Notices |  | 2w | 2019-04-01 | 2019-04-12 | 170d |  |  |
| 62 | 12.3 | Design |  | 5.8w | 2019-05-01 | 2019-06-10 | 156d |  | start no earlier than 2019-05-01 |
| 63 | 12.4 | Construction |  | 24w | 2019-07-01 | 2019-12-13 | 22d |  | start no earlier than 2019-07-01 |
| 65 | 13 | **A4017 (Cleeve Hill) - A4017 Bromley Heath Rd / Cleeve Hill** |  | 180d | 2019-04-01 | 2019-12-09 |  |  |  |
| 66 | 13.1 | Investigation |  | 4w | 2019-04-01 | 2019-04-26 | 160d |  |  |
| 67 | 13.2 | Notices |  | 2w | 2019-04-01 | 2019-04-12 | 170d |  |  |
| 68 | 13.3 | Design |  | 6w | 2019-05-01 | 2019-06-11 | 155d |  | start no earlier than 2019-05-01 |
| 69 | 13.4 | Construction |  | 24w | 2019-07-01 | 2019-12-13 | 22d |  | start no earlier than 2019-07-01 |
| 70 | 14 | **CDM** |  | 475d | 2018-02-19 | 2019-12-16 |  |  |  |
| 71 | 14.1 | Notification | milestone | 0d | 2018-02-19 | 2018-02-19 | 465d |  |  |
| 72 | 14.2 | Pre-Construction Information |  | 4w | 2018-02-19 | 2018-03-16 | 657d |  |  |
| 73 | 14.3 | Construction Phase Plan |  | 6w | 2018-02-19 | 2018-03-30 | 647d |  |  |
| 74 | 14.4 | Records site spefiic information |  | 96w | 2018-02-19 | 2019-12-20 | -5d | 0d |  |
| 75 | 14.5 | Health & Safety Files |  | 2w | 2020-01-01 | 2020-01-14 | 0d |  | start no earlier than 2020-01-01 |
